# Zellomat3D

Schedule from MS Project, 2005-03-14 to 2005-05-06, 12 hours a day.
XyLabs

## Calendars

- Zellomat3D: Mon-Fri 10:00-12:00, 13:00-23:00; Sat 10:00-12:00, 13:00-17:00; Sun off.

## Resources

| Resource |
| --- |
| Michael Florin |
| Andreas Weinmann |

## Schedule

| ID | WBS | Task | Type | Duration | Start | Finish | Predecessors | Total slack | Free slack | Constraint |
| --- | --- | --- | --- | --- | --- | --- | --- | --- | --- | --- |
| 1 | 1 | **Phase 1 Vorbereitung** |  | 2d | 2005-03-14 10:00 | 2005-03-16 08:00 |  | 2.33d |  |  |
| 2 | 1.1 | **Arbeitsumgebung** |  | 0.5d | 2005-03-14 10:00 | 2005-03-14 17:00 |  | 2.67d | 0d |  |
| 3 | 1.1.1 | Software Installation |  | 6h | 2005-03-14 10:00 | 2005-03-14 17:00 |  | 2.67d |  |  |
| 4 | 1.1.2 | Templates |  | 6h | 2005-03-14 10:00 | 2005-03-14 17:00 |  | 2.67d |  |  |
| 5 | 1.2 | **Projektmanagement** |  | 1.17d | 2005-03-14 17:00 | 2005-03-15 19:00 | 2 | 2.67d | 0.33d |  |
| 6 | 1.2.1 | Aufgabenstellung |  | 2h | 2005-03-14 17:00 | 2005-03-14 19:00 |  | 3.67d |  |  |
| 7 | 1.2.2 | Projektpage |  | 12h | 2005-03-14 17:00 | 2005-03-15 17:00 |  | 2.83d |  |  |
| 8 | 1.2.3 | Projekt Management Plan |  | 14h | 2005-03-14 17:00 | 2005-03-15 19:00 |  | 2.67d |  |  |
| 9 | 1.2.4 | Projektplan / Zeiterfassung |  | 8h | 2005-03-14 17:00 | 2005-03-15 12:00 |  | 3.17d |  |  |
| 10 | 1.2.5 | Style Guide |  | 4h | 2005-03-14 17:00 | 2005-03-14 21:00 |  | 3.5d |  |  |
| 11 | 1.3 | Milestone Phase 1 | milestone | 0d | 2005-03-16 08:00 | 2005-03-16 08:00 | 5 | 2.33d | 0d | start no earlier than 2005-03-16 08:00 |
| 13 | 2 | **Phase 2 Analyse** |  | 16.83d | 2005-03-16 10:00 | 2005-04-06 15:00 | 11 | 2d |  |  |
| 14 | 2.1 | **Iteration 1** |  | 2.17d | 2005-03-16 10:00 | 2005-03-18 12:00 |  | 2.33d |  |  |
| 15 | 2.1.1 | **Analyse** |  | 2.17d | 2005-03-16 10:00 | 2005-03-18 12:00 |  | 2.33d | 0d |  |
| 16 | 2.1.1.1 | Anforderungsspezifikation Prototypen |  | 6h | 2005-03-16 10:00 | 2005-03-16 17:00 |  | 2.33d | 0d |  |
| 17 | 2.1.1.2 | Analyse Prototypen |  | 20h | 2005-03-16 17:00 | 2005-03-18 12:00 | 16 | 2.33d |  |  |
| 18 | 2.1.2 | Milestone Phase 2 Iteration 1 | milestone | 0d | 2005-03-18 12:00 | 2005-03-18 12:00 | 15 | 2.33d | 0d |  |
| 19 | 2.2 | **Iteration 2** |  | 2.33d | 2005-04-04 10:00 | 2005-04-06 15:00 | 42 | 2d |  |  |
| 20 | 2.2.1 | **Analyse** |  | 1.33d | 2005-04-04 10:00 | 2005-04-05 15:00 |  | 2d | 0d |  |
| 21 | 2.2.1.1 | Anforderungsspezifikation Applikation |  | 4h | 2005-04-04 10:00 | 2005-04-04 15:00 |  | 2d | 0d |  |
| 22 | 2.2.1.2 | Analyse Applikation |  | 12h | 2005-04-04 15:00 | 2005-04-05 15:00 | 21 | 2d |  |  |
| 23 | 2.2.2 | Reserve Phase 2 Iteration 2 |  | 12h | 2005-04-05 15:00 | 2005-04-06 15:00 | 20 | 2d | 0d |  |
| 24 | 2.2.3 | Milestone Phase 2 Iteration 2 | milestone | 0d | 2005-04-06 15:00 | 2005-04-06 15:00 | 23 | 2d | 0d |  |
| 26 | 3 | **Phase 3 Design** |  | 17.83d | 2005-03-18 13:00 | 2005-04-11 08:00 |  | 2d |  |  |
| 27 | 3.1 | **Iteration 1** |  | 1.33d | 2005-03-18 13:00 | 2005-03-21 08:00 | 18 | 2d |  |  |
| 28 | 3.1.1 | Design Prototypen |  | 12h | 2005-03-18 13:00 | 2005-03-19 12:00 |  | 2.33d | 0.33d |  |
| 29 | 3.1.2 | Milestone Phase 3 Iteration 1 | milestone | 0d | 2005-03-21 08:00 | 2005-03-21 08:00 | 28 | 2d | 0d | start no earlier than 2005-03-21 08:00 |

| ID | WBS | Task | Type | Duration | Start | Finish | Predecessors | Total slack | Free slack | Constraint |
| --- | --- | --- | --- | --- | --- | --- | --- | --- | --- | --- |
| 30 | 3.2 | **Iteration 2** |  | 3.17d | 2005-04-06 15:00 | 2005-04-11 08:00 | 24 | 2d |  |  |
| 31 | 3.2.1 | Design Applikation |  | 16h | 2005-04-06 15:00 | 2005-04-07 19:00 |  | 2d | 0d |  |
| 32 | 3.2.2 | Testspezfikationen |  | 12h | 2005-04-07 19:00 | 2005-04-08 19:00 | 31 | 2d | 0d |  |
| 33 | 3.2.3 | Reserve Phase 3 Iteration 2 |  | 10h | 2005-04-08 19:00 | 2005-04-09 17:00 | 32 | 2d | 0d |  |
| 34 | 3.2.4 | Milestone Phase 3 Iteration 2 | milestone | 0d | 2005-04-11 08:00 | 2005-04-11 08:00 | 33 | 2d | 0d | start no earlier than 2005-04-11 08:00 |
| 36 | 4 | **Phase 4 Implementation** |  | 33d | 2005-03-21 10:00 | 2005-05-02 08:00 |  | 1.83d |  |  |
| 37 | 4.1 | **Iteration 1** |  | 11d | 2005-03-21 10:00 | 2005-04-04 08:00 | 29 | 2d |  |  |
| 38 | 4.1.1 | Prototypen Modul Rohdatenberechnung |  | 110h | 2005-03-21 10:00 | 2005-03-31 19:00 |  | 2d | 0d |  |
| 39 | 4.1.2 | Prototypen Modul Datenaufbereitung |  | 30h | 2005-03-21 10:00 | 2005-03-23 17:00 |  | 8.67d | 6.67d |  |
| 40 | 4.1.3 | Prototypen Modul Visualisierung |  | 80h | 2005-03-21 10:00 | 2005-03-29 12:00 |  | 4.5d | 2.5d |  |
| 41 | 4.1.4 | Reserve Phase 4 Iteration 1 |  | 22h | 2005-03-31 19:00 | 2005-04-02 17:00 | 38, 39, 40 | 2d | 0d |  |
| 42 | 4.1.5 | Milestone Phase 4 Iteration 1 | milestone | 0d | 2005-04-04 08:00 | 2005-04-04 08:00 | 41 | 2d | 0d | start no earlier than 2005-04-04 08:00 |
| 43 | 4.2 | **Iteration 2** |  | 16.5d | 2005-04-11 10:00 | 2005-05-02 08:00 | 34 | 1.83d |  |  |
| 44 | 4.2.1 | **Modul Rohdatenberechnung** |  | 4.17d | 2005-04-11 10:00 | 2005-04-15 12:00 |  | 2d | 0d |  |
| 45 | 4.2.1.1 | Implementation |  | 40h | 2005-04-11 10:00 | 2005-04-14 15:00 |  | 2d | 0d |  |
| 46 | 4.2.1.2 | Testing |  | 6h | 2005-04-14 15:00 | 2005-04-14 21:00 | 45 | 2d | 0d |  |
| 47 | 4.2.1.3 | Performancemessung |  | 4h | 2005-04-14 21:00 | 2005-04-15 12:00 | 46 | 2d |  |  |
| 48 | 4.2.2 | **Modul Datenaufbereitung** |  | 3.33d | 2005-04-15 13:00 | 2005-04-19 23:00 | 44 | 2d | 0d |  |
| 49 | 4.2.2.1 | Implementation |  | 34h | 2005-04-15 13:00 | 2005-04-19 17:00 |  | 2d | 0d |  |
| 50 | 4.2.2.2 | Testing |  | 4h | 2005-04-19 17:00 | 2005-04-19 21:00 | 49 | 2d | 0d |  |
| 51 | 4.2.2.3 | Performancemessung |  | 2h | 2005-04-19 21:00 | 2005-04-19 23:00 | 50 | 2d |  |  |
| 52 | 4.2.3 | **Modul Visualisierung** |  | 6.67d | 2005-04-11 10:00 | 2005-04-19 12:00 |  | 2.83d | 0.83d |  |
| 53 | 4.2.3.1 | Implementation |  | 70h | 2005-04-11 10:00 | 2005-04-18 15:00 |  | 2.83d | 0d |  |
| 54 | 4.2.3.2 | Testing |  | 6h | 2005-04-18 15:00 | 2005-04-18 21:00 | 53 | 2.83d | 0d |  |
| 55 | 4.2.3.3 | Performancemessung |  | 4h | 2005-04-18 21:00 | 2005-04-19 12:00 | 54 | 2.83d |  |  |

| ID | WBS | Task | Type | Duration | Start | Finish | Predecessors | Total slack | Free slack | Constraint |
| --- | --- | --- | --- | --- | --- | --- | --- | --- | --- | --- |
| 56 | 4.2.4 | **Deployment Programm** |  | 4.17d | 2005-04-20 10:00 | 2005-04-25 19:00 | 48, 52 | 2d | 0d |  |
| 57 | 4.2.4.1 | Zusammensetzen der Module |  | 40h | 2005-04-20 10:00 | 2005-04-23 15:00 |  | 2d | 0d |  |
| 58 | 4.2.4.2 | Modul Programmsteuerung |  | 30h | 2005-04-20 10:00 | 2005-04-22 17:00 |  | 2.83d | 0.83d |  |
| 59 | 4.2.4.3 | Testing Programm Zellomat3D |  | 10h | 2005-04-23 15:00 | 2005-04-25 19:00 | 58, 57 | 2d |  |  |
| 60 | 4.2.5 | Automatenentwicklung |  | 24h | 2005-04-25 19:00 | 2005-04-27 19:00 | 56 | 2d | 0d |  |
| 61 | 4.2.6 | Reserve Phase 4 Iteration 2 |  | 32h | 2005-04-27 19:00 | 2005-04-30 15:00 | 60 | 2d | 0.17d |  |
| 62 | 4.2.7 | Milestone Phase 4 Iteration 2 | milestone | 0d | 2005-05-02 08:00 | 2005-05-02 08:00 | 61 | 1.83d | 0d | start no earlier than 2005-05-02 08:00 |
| 64 | 5 | **Phase 5 Abschluss** |  | 4d | 2005-05-02 10:00 | 2005-05-06 08:00 | 62 | 0d |  |  |
| 65 | 5.1 | **Berichte** |  | 1d | 2005-05-02 10:00 | 2005-05-02 23:00 |  | 1.83d | 0d |  |
| 66 | 5.1.1 | Technischer Bericht |  | 12h | 2005-05-02 10:00 | 2005-05-02 23:00 |  | 1.83d |  |  |
| 67 | 5.1.2 | Management Summary |  | 4h | 2005-05-02 10:00 | 2005-05-02 15:00 |  | 2.5d |  |  |
| 68 | 5.1.3 | Kurzfassung / Abstract |  | 2h | 2005-05-02 10:00 | 2005-05-02 12:00 |  | 2.67d |  |  |
| 69 | 5.1.4 | Persönliche Berichte |  | 1h | 2005-05-02 10:00 | 2005-05-02 11:00 |  | 2.75d |  |  |
| 70 | 5.2 | **Referenzen** |  | 0.17d | 2005-05-03 10:00 | 2005-05-03 12:00 | 65 | 1.83d | 0d |  |
| 71 | 5.2.1 | Dokumentenplan |  | 2h | 2005-05-03 10:00 | 2005-05-03 12:00 |  | 1.83d |  |  |
| 72 | 5.2.2 | Glossar |  | 2h | 2005-05-03 10:00 | 2005-05-03 12:00 |  | 1.83d |  |  |
| 73 | 5.2.3 | Literaturverzeichnis |  | 2h | 2005-05-03 10:00 | 2005-05-03 12:00 |  | 1.83d |  |  |
| 74 | 5.3 | **Handbücher** |  | 1d | 2005-05-02 10:00 | 2005-05-02 23:00 |  | 2d | 0.17d |  |
| 75 | 5.3.1 | Installationsanleitung |  | 12h | 2005-05-02 10:00 | 2005-05-02 23:00 |  | 2d |  |  |
| 76 | 5.3.2 | Benutzerhandbuch |  | 12h | 2005-05-02 10:00 | 2005-05-02 23:00 |  | 2d |  |  |
| 77 | 5.4 | **Abschluss** |  | 1d | 2005-05-03 13:00 | 2005-05-04 12:00 | 65, 70, 74 | 1.83d |  |  |
| 78 | 5.4.1 | Interner Abschluss |  | 12h | 2005-05-03 13:00 | 2005-05-04 12:00 |  | 1.83d |  |  |
| 79 | 5.4.2 | Abnahme |  | 2h | 2005-05-03 13:00 | 2005-05-03 15:00 |  | 2.67d |  |  |
| 80 | 5.5 | Milestone Phase 5 | milestone | 0d | 2005-05-06 08:00 | 2005-05-06 08:00 | 77 | 0d |  | start no earlier than 2005-05-06 08:00 |
